# Cronograma de Ejecución

Schedule from MS Project, 2023-04-01 to 2023-12-22.

## Calendars

- Estándar: Mon-Sat 09:00-13:00, 15:00-19:00; Sun off. Exceptions (off unless hours are given): 2023-05-01 (Dia del Trabajo), 2023-06-29 (San Pedro y San Pablo), 2023-07-28 to 2023-07-29 (Fiestas Patrias), 2023-08-30 (Santa Rosa de Lima), 2023-11-01 (Dia de los Santos).

## Resources

| Resource |
| --- |
| Cargador Frontal L 150G |
| Excavadora Hyundai con picoton |
| Excavadora EC 380DL |
| Excavadora Cat 360 (Uña Roquera) |
| Cargador Frontal L 150G |
| Cargador Frontal L 120F |
| Motoniveladora de 140 HP |
| Rodillo Liso Vibratorio Autopropulsado 10-12 Tn |
| Volquetes de 6x4 |

## Schedule

| ID | WBS | Task | Type | Duration | Start | Finish | Predecessors | Total slack | Free slack | Constraint | Dias Calendario |
| --- | --- | --- | --- | --- | --- | --- | --- | --- | --- | --- | --- |
| 1 | 1 | **HABILITACIÓN DE ACCESOS , PLATAFORMAS Y MOVIMIENTO DE TIERRAS II PARTE- CUENCA HUAURA** |  | 222d | 2023-04-01 | 2023-12-22 |  | 0d |  |  | 266 días |
| 2 | 1.1 | INICIO DE OBRA: PAQUETE 02 | milestone | 0d | 2023-04-01 | 2023-04-01 |  | 0d |  | start no earlier than 2023-04-01 | 0 días |
| 3 | 1.2 | **OBRAS PROVISIONALES** |  | 222d | 2023-04-01 | 2023-12-22 |  | 0d |  |  | 1 días |
| 4 | 1.2.1 | CAMPAMENTO PROVISIONAL DE OBRA |  | 15d | 2023-04-01 | 2023-04-18 | 2SS | 207d | 0d | start no earlier than 2023-04-01 | 18 días |
| 5 | 1.2.2 | MOVILIZACION Y DESMOVILIZACION DE MAQUINARIA PESADA |  | 30d | 2023-04-01 | 2023-12-20 | 2SS | 0d |  |  | 264 días |
| 6 | 1.2.3 | MEJORAMIENTO Y HABILITACIÓN DE CAMINOS DE ACCESO |  | 30d | 2023-04-01 | 2023-05-06 | 2SS | 0d |  |  | 36 días |
| 7 | 1.2.4 | LIMPIEZA MANUAL DE MATERIAL VEGETAL Y DE RESIDUOS |  | 6d | 2023-04-01 | 2023-04-07 | 4SS | 216d |  |  | 7 días |
| 8 | 1.2.5 | MANTENIMIENTO DE CAMINOS DE ACCESO |  | 217d | 2023-04-07 | 2023-12-22 | 6SS+5d | 0d |  |  | 260 días |
| 9 | 1.2.6 | TUBERÍA HDPE CORRUGADA Ø=630MM, PARA CAMINOS DE ACCESO (O SIMILAR) |  | 30d | 2023-04-01 | 2023-05-06 | 6SS | 192d | 0d |  | 36 días |
| 10 | 1.2.7 | TUBERÍA HDPE CORRUGADA Ø=1000MM, PARA CAMINOS DE ACCESO (O SIMILAR) |  | 30d | 2023-04-01 | 2023-05-06 | 9SS | 192d |  |  | 36 días |
| 11 | 1.3 | **TOPOGRAFÍA** |  | 220d | 2023-04-01 | 2023-12-20 |  | 2d |  |  | 1 días |
| 12 | 1.3.1 | TRAZO Y REPLANTEO DURANTE LA OBRA |  | 220d | 2023-04-01 | 2023-12-20 | 2SS | 2d |  |  | 264 días |
| 13 | 1.4 | **EXCAVACIONES** |  | 125d | 2023-04-04 | 2023-09-01 |  | 0d |  |  | 1 días |
| 14 | 1.4.1 | DESBROCE |  | 50d | 2023-04-04 | 2023-06-01 | 5SS+2d | 0d |  |  | 59 días |
| 15 | 1.4.2 | REMOCIÓN DE DIQUE EXISTENTE |  | 30d | 2023-04-10 | 2023-05-15 | 14SS+5d | 65d | 0d |  | 36 días |
| 16 | 1.4.3 | EXCAVACION DE CIMENTACIÓN |  | 120d | 2023-04-10 | 2023-09-01 | 14SS+5d | 0d |  |  | 145 días |
| 17 | 1.4.4 | PERFILADO Y CONFORMACIÓN DE PLATAFORMA DE FUNDACIÓN |  | 60d | 2023-04-27 | 2023-07-07 | 16SS+15d | 0d |  |  | 72 días |
| 18 | 1.4.5 | EXCAVACION DE UÑA |  | 120d | 2023-04-10 | 2023-09-01 | 16SS | 95d | 0d |  | 145 días |
| 19 | 1.4.6 | CONFORMACIÓN DE MATERIAL EXCEDENTE EN DME |  | 120d | 2023-04-10 | 2023-09-01 | 16SS | 95d |  |  | 145 días |
| 20 | 1.4.7 | CONFORMACIÓN DE MATERIAL EXCEDENTE EN DMO |  | 50d | 2023-04-04 | 2023-06-01 | 14SS | 170d |  |  | 59 días |
| 21 | 1.4.8 | EXCAVACIÓN LOCALIZADA - SOBREEXCAVACIÓN |  | 120d | 2023-04-10 | 2023-09-01 | 18SS | 95d |  |  | 145 días |
| 22 | 1.5 | **RELLENOS** |  | 175d | 2023-04-29 | 2023-11-25 |  | 0d |  |  | 1 días |
| 23 | 1.5.1 | RELLENO CON MATERIAL GRANULAR (INCLUYE EXTRACCIÓN DE MATERIAL, ZARANDEO Y COMBINACIÓN DE MATERIAL) |  | 150d | 2023-04-29 | 2023-10-26 | 17SS+2d | 0d |  |  | 181 días |
| 24 | 1.5.2 | RELLENO SIN COMPACTAR |  | 50d | 2023-08-29 | 2023-10-26 | 23SS+100d | 48d |  |  | 59 días |
| 25 | 1.5.3 | RELLENO AFIRMADO |  | 150d | 2023-05-18 | 2023-11-14 | 23SS+15d | 33d | 0d |  | 181 días |
| 26 | 1.5.4 | PERFILADO DE TALUD DEL DIQUE |  | 150d | 2023-05-06 | 2023-11-02 | 23SS+5d | 43d |  |  | 181 días |
| 27 | 1.5.5 | RELLENO CON MATERIAL SELECCIONADO (INCLUYE EXTRACCIÓN DE MATERIAL, ZARANDEO Y COMBINACIÓN DE MATERIAL) EN SOBREEXCAVACIÓN |  | 15d | 2023-10-27 | 2023-11-14 | 23 | 23d | 0d |  | 19 días |
| 28 | 1.5.6 | GRAVA PARA DRENAJE |  | 10d | 2023-11-15 | 2023-11-25 | 27 | 23d |  |  | 11 días |

| ID | WBS | Task | Duration | Start | Finish | Predecessors | Total slack | Free slack | Constraint | Dias Calendario |
| --- | --- | --- | --- | --- | --- | --- | --- | --- | --- | --- |
| 29 | 1.6 | **GEOTEXTILES** | 155d | 2023-05-12 | 2023-11-14 |  | 5d |  |  | 1 días |
| 30 | 1.6.1 | INSTALACIÓN DE GEOTEXTIL 400 GR/M2 | 150d | 2023-05-18 | 2023-11-14 | 23SS+15d | 0d |  |  | 181 días |
| 31 | 1.6.2 | ZANJA DE ANCLAJE | 150d | 2023-05-12 | 2023-11-08 | 23SS+10d | 38d |  |  | 181 días |
| 32 | 1.7 | **COLOCACIÓN DE ROCA** | 207d | 2023-04-10 | 2023-12-13 |  | 8d |  |  | 1 días |
| 33 | 1.7.1 | COLOCACIÓN DE ROCA EN UÑA | 150d | 2023-05-30 | 2023-11-25 | 30SS+10d | 0d |  |  | 180 días |
| 34 | 1.7.2 | COLOCACIÓN DE ROCA EN TALUD | 150d | 2023-06-16 | 2023-12-13 | 33SS+15d | 0d |  |  | 181 días |
| 35 | 1.7.3 | EXTRACCIÓN Y SELECCIÓN DE ROCAS REUTILIZABLES (50% DE ROCA UTILIZABLE) | 50d | 2023-04-10 | 2023-06-07 | 15SS | 165d |  |  | 59 días |
| 36 | 1.8 | **TRANSPORTES** | 212d | 2023-04-04 | 2023-12-13 |  | 8d |  |  | 1 días |
| 37 | 1.8.1 | TRANSPORTE DE MATERIAL ORGÁNICO (A DMO) D<=1KM | 50d | 2023-04-04 | 2023-06-01 | 14SS | 170d | 0d |  | 59 días |
| 38 | 1.8.2 | TRANSPORTE DE MATERIAL ORGÁNICO (A DMO) D>1KM | 50d | 2023-04-04 | 2023-06-01 | 37SS | 170d |  |  | 59 días |
| 39 | 1.8.3 | TRANSPORTE DE MATERIAL EXCEDENTE D<= 1KM | 120d | 2023-04-10 | 2023-09-01 | 16SS | 95d | 0d |  | 145 días |
| 40 | 1.8.4 | TRANSPORTE DE MATERIAL EXCEDENTE D> 1KM | 120d | 2023-04-10 | 2023-09-01 | 39SS | 95d |  |  | 145 días |
| 41 | 1.8.5 | TRANSPORTE DE MATERIAL DE PRESTAMO (AFIRMADO) D<= 1KM | 150d | 2023-05-18 | 2023-11-14 | 25SS | 33d | 0d |  | 181 días |
| 42 | 1.8.6 | TRANSPORTE DE MATERIAL DE PRESTAMO (AFIRMADO) D> 1KM | 150d | 2023-05-18 | 2023-11-14 | 41SS | 33d |  |  | 181 días |
| 43 | 1.8.7 | TRANSPORTE DE ROCA D<=1KM | 165d | 2023-05-30 | 2023-12-13 | 33SS | 8d | 0d | finish no earlier than 2023-12-06 | 198 días |
| 44 | 1.8.8 | TRANSPORTE DE ROCA D>1KM | 165d | 2023-05-30 | 2023-12-13 | 43SS | 8d |  |  | 198 días |
| 45 | 1.8.9 | TRANSPORTE DE MATERIAL DE PRÉSTAMO CANTERA DE RIO (CUERPO DE TERRAPLÉN) D<=1KM | 165d | 2023-04-29 | 2023-11-14 | 23SS | 33d | 0d |  | 200 días |
| 46 | 1.8.10 | TRANSPORTE DE MATERIAL DE PRÉSTAMO CANTERA DE RIO (CUERPO DE TERRAPLÉN) D>1KM | 165d | 2023-04-29 | 2023-11-14 | 45SS | 33d |  |  | 200 días |
| 47 | 1.9 | **OBRAS CIVILES (INTERFERENCIAS)** | 150d | 2023-04-10 | 2023-10-06 |  | 65d |  |  | 1 días |
| 48 | 1.9.1 | TRAZO Y REPLANTEO DE INTERFERENCIA | 15d | 2023-04-10 | 2023-04-26 | 15SS | 65d | 0d |  | 17 días |
| 49 | 1.9.2 | DESVÍO PROVISIONAL CON TUBERÍA | 15d | 2023-04-27 | 2023-05-15 | 48 | 65d | 0d |  | 19 días |
| 50 | 1.9.3 | DESVÍO PROVISIONAL EN TIERRAS | 15d | 2023-04-27 | 2023-05-15 | 49SS | 65d | 0d |  | 19 días |
| 51 | 1.9.4 | LIMPIEZA DE TERRENO MANUAL | 15d | 2023-05-10 | 2023-05-26 | 50SS+10d | 65d | 0d |  | 17 días |
| 52 | 1.9.5 | EXCAVACIONES NO CLASIFICADA PARA ESTRUCTURAS | 5d | 2023-05-27 | 2023-06-01 | 51 | 65d | 0d |  | 6 días |
| 53 | 1.9.6 | EXCAVACION NO CLASIFICADA DE ZANJA | 5d | 2023-05-27 | 2023-06-01 | 52SS | 65d | 0d |  | 6 días |
| 54 | 1.9.7 | RELLENO ESTRUCTURAL | 5d | 2023-06-02 | 2023-06-07 | 53 | 65d | 0d |  | 6 días |
| 55 | 1.9.8 | SUMINISTRO DE ROCA (ALCANTARILLAS) | 10d | 2023-06-08 | 2023-06-19 | 54 | 65d | 0d |  | 12 días |
| 56 | 1.9.9 | COLOCACIÓN DE ROCA EN UÑA (ALCANTARILLAS) | 5d | 2023-06-20 | 2023-06-24 | 55 | 65d | 0d |  | 5 días |
| 57 | 1.9.10 | CONCRETO DE NIVELACION (F'C=100 KG/CM2) | 5d | 2023-06-26 | 2023-07-01 | 56 | 65d | 0d |  | 6 días |
| 58 | 1.9.11 | CONCRETO CLASE F (F'C=140 KG/CM2) | 5d | 2023-07-03 | 2023-07-07 | 57 | 65d | 0d |  | 5 días |
| 59 | 1.9.12 | CONCRETO CLASE C (F'C=280 KG/CM2) PREMEZCLADO - CIMIENTOS REFORZADOS | 5d | 2023-07-08 | 2023-07-13 | 58 | 65d | 0d |  | 6 días |
| 60 | 1.9.13 | CONCRETO CLASE C (F'C=280 KG/CM2) PREMEZCLADO - MUROS DE CONTENCION | 5d | 2023-07-14 | 2023-07-19 | 59 | 65d | 0d |  | 6 días |
| 61 | 1.9.14 | ENCOFRADO Y DESENCOFRADO CARAVISTA | 15d | 2023-06-26 | 2023-07-13 | 57SS | 135d | 0d |  | 18 días |
| 62 | 1.9.15 | ENCOFRADO Y DESENCOFRADO CARA OCULTA | 15d | 2023-06-26 | 2023-07-13 | 61SS | 135d |  |  | 18 días |
| 63 | 1.9.16 | ACERO DE REFUERZO F'Y=4200KG/CM2 | 15d | 2023-06-26 | 2023-07-13 | 61SS | 135d |  |  | 18 días |
| 64 | 1.9.17 | EMBOQUILLADO DE PIEDRA E=0.20M | 5d | 2023-07-20 | 2023-07-25 | 60 | 65d | 0d |  | 6 días |
| 65 | 1.9.18 | EMBOQUILLADO DE PIEDRA E=0.30M | 10d | 2023-07-26 | 2023-08-08 | 64 | 65d | 0d |  | 14 días |
| 66 | 1.9.19 | EMBOQUILLADO DE PIEDRA E=0.50M | 5d | 2023-08-09 | 2023-08-14 | 65 | 65d | 0d |  | 6 días |
| 67 | 1.9.20 | CAMA DE ARENA E=0.20M | 5d | 2023-08-15 | 2023-08-19 | 66 | 65d | 0d |  | 5 días |
| 68 | 1.9.21 | TUBERÍA HDPE CORRUGADA Ø=900MM (SUMINISTRO E INSTALACIÓN) | 5d | 2023-08-21 | 2023-08-25 | 67 | 65d | 0d |  | 5 días |
| 69 | 1.9.22 | TUBERÍA HDPE CORRUGADA Ø=1200MM (SUMINISTRO E INSTALACIÓN) | 5d | 2023-08-26 | 2023-09-01 | 68 | 65d | 0d |  | 7 días |
| 70 | 1.9.23 | COMPUERTAS CHARNELA Ø900 (SUMINISTRO E INSTALACION) | 10d | 2023-09-02 | 2023-09-13 | 69 | 65d | 0d |  | 12 días |
| 71 | 1.9.24 | COMPUERTAS CHARNELA Ø1200 (SUMINISTRO E INSTALACION) | 10d | 2023-09-14 | 2023-09-25 | 70 | 65d | 0d |  | 12 días |
| 72 | 1.9.25 | COMPUERTA METÁLICA TIPO TARJETA 1.00x1.00 cm (SUMINISTRO E INSTALACIÓN) | 10d | 2023-09-26 | 2023-10-06 | 71 | 65d |  |  | 11 días |
| 73 | 1.9.26 | SELLO EN JUNTAS | 5d | 2023-07-20 | 2023-07-25 | 60 | 110d | 0d |  | 6 días |
| 74 | 1.9.27 | WATERSTOP (ANILLOS DE ESTANQUEIDAD) | 5d | 2023-07-26 | 2023-08-02 | 73 | 110d | 0d |  | 8 días |
| 75 | 1.9.28 | PINTURA BITUMINOSA | 10d | 2023-08-03 | 2023-08-14 | 74 | 110d |  |  | 12 días |
| 76 | 1.9.29 | RELLENO CON MATERIAL GRANULAR (INCLUYE EXTRACCIÓN DE MATERIAL, ZARANDEO Y COMBINACIÓN DE MATERIAL) | 5d | 2023-08-15 | 2023-08-19 | 66 | 105d |  |  | 5 días |

| ID | WBS | Task | Duration | Start | Finish | Predecessors | Total slack | Dias Calendario |
| --- | --- | --- | --- | --- | --- | --- | --- | --- |
| 77 | 1.10 | **ACCESOS** | 8d | 2023-12-14 | 2023-12-22 |  | 0d | 1 días |
| 78 | 1.10.1 | **SUPERFICIE DE RODADURA** | 8d | 2023-12-14 | 2023-12-22 |  | 0d | 1 días |
| 79 | 1.10.1.1 | CONCRETO CLASE C (F'C=280 KG/CM2) EN LOSA | 6d | 2023-12-16 | 2023-12-22 | 80SS+2d | 0d | 7 días |
| 80 | 1.10.1.2 | ENCOFRADO Y DESENCOFRADO PAVIMENTO RÍGIDO E=0.15M | 6d | 2023-12-14 | 2023-12-20 | 34 | 0d | 7 días |
| 81 | 1.10.1.3 | JUNTA EN PAVIMENTOS CON PASADORES | 6d | 2023-12-14 | 2023-12-20 | 80SS | 2d | 7 días |
| 82 | 1.10.1.4 | CONCRETO CICLOPEO F'C=210 KG/CM2 + 30% PM | 6d | 2023-12-16 | 2023-12-22 | 79SS | 0d | 7 días |
